# PROGRAMACIÓN PRORROGA (OCT-NOV) JOT

Schedule from MS Project, 2026-10-01 to 2026-12-02.

## Calendars

- Estándar: Mon-Fri 09:00-13:00, 15:00-19:00; Sat-Sun off.

## Schedule

| ID | WBS | Task | Duration | Start | Finish | Predecessors | Total slack | Free slack |
| --- | --- | --- | --- | --- | --- | --- | --- | --- |
| 1 | 1 | **CIV 8** | 45d | 2026-10-01 | 2026-12-02 |  |  |  |
| 2 | 1.1 | REPLANTEO GENERAL | 2.25d | 2026-10-01 | 2026-10-05 |  | 0.62d | 0d |
| 3 | 1.2 | EXCAVACIÓN MECÁNICA EN MATERIAL COMÚN (INCLUYE CARGUE) | 8d | 2026-10-05 | 2026-10-15 | 2 | 0.62d | 0d |
| 4 | 1.3 | EXCAVACION MANUAL EN MATERIAL COMUN. INCLUYE CARGUE. | 1d | 2026-11-20 | 2026-11-23 | 8 | 0.62d | 0d |
| 5 | 1.4 | NIVELACIÓN Y COMPACTACIÓN DE SUBRASANTE PARA ESPACIO PÚBLICO | 1d | 2026-11-12 | 2026-11-13 | 22 | 0.62d | 0d |
| 6 | 1.5 | GEOTEXTIL T, RESIST. ULTIMA (TIRA ANCHA)=90 KN/M PARA SEPARACION SUBRASANTE/CAPAS GRANULARES (INC. SUMIN. E INSTALACIÓN) | 1d | 2026-11-13 | 2026-11-16 | 5 | 0.62d | 0d |
| 7 | 1.6 | AGREGADOS RECICLADOS PARA SUBBASE GRANULAR (AR_SBG50) (Suministro, Extendido, Nivelación, Humedecimiento y Compactación con vibrocompactador) | 2d | 2026-11-16 | 2026-11-18 | 6 | 0.62d | 0d |
| 8 | 1.7 | SUBBASE GRANULAR PEATONAL SBG_PEA. SUMINISTRO, EXTENDIDO MANUAL, NIVELACIÓN, HUMEDECIMIENTO Y COMPACTACIÓN | 2d | 2026-11-18 | 2026-11-20 | 7 | 0.62d | 0d |
| 9 | 1.8 | BORDILLO PREFABRICADO A80 (SUMINISTRO E INSTALACIÓN. INCLUYE 3CM MORTERO DE NIVELACIÓN 2000 PSI) | 1d | 2026-11-23 | 2026-11-24 | 8, 4 | 0.62d | 0d |
| 10 | 1.9 | PISO EN CONCRETO ESTAMPADO DE COLOR SUPERFICIAL GRIS. E=0,12M. (INCLUYE SUMINISTRO Y COLOCACIÓN DE CONCRETO, ENDURECEDOR COLOR GRIS | 1d | 2026-11-30 | 2026-12-01 | 11 | 0.62d | 0d |
| 11 | 1.10 | CENEFA EN LOSETA PREFABRICADA A57 TÁCTIL ALERTA (20X20X6) CM. SUMINISTRO E INSTALACIÓN. (INCLUYE 4CM DE MORTERO 1:5 HECHO EN OBRA PARA BASE Y ARENA DE PEÑA PARA SELLO) | 1d | 2026-11-27 | 2026-11-30 | 17 | 0.62d | 0d |
| 12 | 1.11 | BARANDA METALICA M-82 PREFABRICADA (INCLUYE INSTALACIÓN, DADOS DE CONCRETO 3000 PSI GRAVA COMÚN DE 0.20 X 0.20 MT Y PINTURA). SUMINISTRO E INSTALACION. | 1d | 2026-12-01 | 2026-12-02 | 10 | 0.62d |  |
| 13 | 1.12 | MALLA ELECTROSOLDADA 0.25X0.25M, D=4MM, 4MM (INCLUYE SUMINISTRO, FIJACIÓN E INSTALACIÓN) | 2h | 2026-11-30 | 2026-11-30 | 11 | 2.38d |  |
| 14 | 1.13 | ACERO DE REFUERZO FY=60000 PSI. SUMINISTRO E INSTALACIÓN. DE ACUERDO A LO ESTIPULADO POR LA NSR-10, NORMA ASTM A-706, ICONTEC 2289 PARA EL ACERO PDR-60. INCLUYE TODOS LOS COSTOS DE SUMINISTRO DE MATERIALES (REFUERZO (G60) FIGURADO, CORRUGADO, INCLUYE EL | 4h | 2026-11-24 | 2026-11-24 | 9 | 6.25d |  |
| 15 | 1.14 | (DOVELAS) ACERO LISO PARA TRANSFERENCIA DE LOSAS D= 1" (NO INCLUYE CANASTILLA). SUMINISTRO E INSTALACIÓN. | 4h | 2026-11-24 | 2026-11-24 | 9 | 6.25d |  |
| 16 | 1.15 | CANASTILLA PASAJUNTAS (INCLUYE SUMINISTRO Y FIJACIÓN) | 1h | 2026-11-24 | 2026-11-24 | 9 | 0.62d | 0d |
| 17 | 1.16 | CONSTRUCCIÓN DE PAVIMENTO RÍGIDO: LOSAS EN CONCRETO HIDRÁULICO MR45 E=0.18M acelerado 7 días | 3d | 2026-11-24 | 2026-11-27 | 16 | 0.62d | 0d |
| 18 | 1.17 | GEODREN (RED DRENANTE DE POLIETILENO DE ALTA DENSIDAD PEAD-HDPE Y GEOTEXTIL NO TEJIDO) CON ALTURA DE 1.0 M. (SUMINISTRO E INSTALACION). | 4d | 2026-10-27 | 2026-11-02 | 19 | 0.62d | 0d |
| 19 | 1.18 | GEOCOMPUESTO PARA DRENAJE, CONFORMADO POR GEODREN (RED DRENANTE DE POLIETILENO DE ALTA DENSIDAD PEAD-HDPE Y GEOTEXTIL NO TEJIDO) CON ALTURA DE 0.5 M Y TUBERIA FLEXIBLE CORRUGADA DE DRENAJE CON DIAMETRO DE 100 MM. (INCLUYE SUMINISTRO E INSTALACION). | 4d | 2026-10-21 | 2026-10-27 | 20 | 0.62d | 0d |
| 20 | 1.19 | GEOTEXTIL TEJIDO CON RESISTENCIA A LA TENSION METODO TIRA ANCHA SENTIDO LONGITUDINAL: ENTRE 30 KN/M Y 39 KN/M. PARA SUBDRENES/FILTROS. (INCLUYE SUMINISTRO E INSTALACION). | 4d | 2026-10-15 | 2026-10-21 | 3 | 0.62d | 0d |
| 21 | 1.20 | GEOMALLA UNIAXIAL RESISTENCIA ÚLTIMA 60KN/MK PARA REFUERZO DE MATERIALES GRANULARES. (INCLUYE SUMINISTRO E INSTALACIÓN) | 4d | 2026-11-02 | 2026-11-06 | 18 | 0.62d | 0d |
| 22 | 1.21 | BOLSA DE LONA RELLENA DE ARENA DE PEÑA. (INCLUYE SUMINISTRO E INSTALACIÓN). | 4d | 2026-11-06 | 2026-11-12 | 21 | 0.62d | 0d |
| 23 | 1.22 | **CIV 3** | 45d | 2026-10-01 | 2026-12-02 |  | 0d |  |
| 24 | 1.22.1 | REPLANTEO GENERAL | 1d | 2026-10-01 | 2026-10-01 |  | 0d |  |
| 25 | 1.22.2 | EXCAVACION MANUAL EN MATERIAL COMUN. INCLUYE CARGUE. | 12d | 2026-10-02 | 2026-10-19 | 24 | 0d |  |
| 26 | 1.22.3 | NIVELACIÓN Y COMPACTACIÓN DE SUBRASANTE PARA ESPACIO PÚBLICO | 6d | 2026-10-20 | 2026-10-27 | 25 | 0d |  |
| 27 | 1.22.4 | GEOTEXTIL T, RESIST. ULTIMA (TIRA ANCHA)=90 KN/M PARA SEPARACION SUBRASANTE/CAPAS GRANULARES (INC. SUMIN. E INSTALACIÓN) | 2d | 2026-10-28 | 2026-10-29 | 26 | 0d |  |
| 28 | 1.22.5 | SUBBASE GRANULAR PEATONAL SBG_PEA. SUMINISTRO, EXTENDIDO MANUAL, NIVELACIÓN, HUMEDECIMIENTO Y COMPACTACIÓN | 6d | 2026-10-30 | 2026-11-06 | 27 | 0d |  |
| 29 | 1.22.6 | PISO EN CONCRETO ESTAMPADO DE COLOR SUPERFICIAL GRIS. E=0,12M. (INCLUYE SUMINISTRO Y COLOCACIÓN DE CONCRETO, ENDURECEDOR COLOR GRIS | 5d | 2026-11-12 | 2026-11-18 | 30 | 0d |  |
| 30 | 1.22.7 | CENEFA EN LOSETA PREFABRICADA A57 TÁCTIL ALERTA (20X20X6) CM. SUMINISTRO E INSTALACIÓN. (INCLUYE 4CM DE MORTERO 1:5 HECHO EN OBRA PARA BASE Y ARENA DE PEÑA PARA SELLO) | 3d | 2026-11-09 | 2026-11-11 | 28 | 0d |  |
| 31 | 1.22.8 | BARANDA METALICA M-82 PREFABRICADA (INCLUYE INSTALACIÓN, DADOS DE CONCRETO 3000 PSI GRAVA COMÚN DE 0.20 X 0.20 MT Y PINTURA). SUMINISTRO E INSTALACION. | 5d | 2026-11-05 | 2026-11-11 | 41 | 15d |  |
| 32 | 1.22.9 | MALLA ELECTROSOLDADA 0.25X0.25M, D=4MM, 4MM (INCLUYE SUMINISTRO, FIJACIÓN E INSTALACIÓN) | 1d | 2026-11-09 | 2026-11-09 | 28 | 17d |  |
| 33 | 1.22.10 | MURO EN BLOQUE DE CONCRETO ESTRIADO. CONSTRUCCIÓN. SUMINISTRO E INSTALACIÓN. INCLUYE BLOQUE ESTRUCTURAL (19cm X 19cm X 39cm) MORTERO 1:3 HECHO EN OBRA PARA PEGA, CORTADORA Y DISCO DIAMANTADO. NO INCLUYE ACERO DE REFUERZO, CONCRETO PARA INYECCIÓN DE DOVELA | 7d | 2026-11-19 | 2026-11-27 | 29 | 0d |  |
| 34 | 1.22.11 | GROUTING 2500 PSI (INCLUYE SUMINISTRO Y COLOCACIÓN) | 5d | 2026-11-26 | 2026-12-02 | 33SS+5d | 0d |  |
| 35 | 1.22.12 | ACERO DE REFUERZO FY=60000 PSI. SUMINISTRO E INSTALACIÓN. DE ACUERDO A LO ESTIPULADO POR LA NSR-10, NORMA ASTM A-706, ICONTEC 2289 PARA EL ACERO PDR-60. INCLUYE TODOS LOS COSTOS DE SUMINISTRO DE MATERIALES (REFUERZO (G60) FIGURADO, CORRUGADO, INCLUYE EL | 3d | 2026-10-20 | 2026-10-22 | 25 | 15d | 0d |
| 36 | 1.22.13 | CONCRETO 3500 PSI ACELERADO A 7 DÍAS PARA MURO DE CONTENCIÓN (INCLUYE SUMINISTRO, TRANSPORTE E INSTALACIÓN) (PANTALLA DE CONCRETO) | 7d | 2026-10-23 | 2026-11-02 | 35SS+3d | 16d | 0d |
| 37 | 1.22.14 | (DOVELAS) ACERO LISO PARA TRANSFERENCIA DE LOSAS D= 1" (NO INCLUYE CANASTILLA). SUMINISTRO E INSTALACIÓN. | 3d | 2026-11-03 | 2026-11-05 | 36 | 16d | 0d |
| 38 | 1.22.15 | CANASTILLA PASAJUNTAS (INCLUYE SUMINISTRO Y FIJACIÓN) | 3d | 2026-11-03 | 2026-11-05 | 36 | 16d | 0d |
| 39 | 1.22.16 | CONSTRUCCIÓN DE PAVIMENTO RÍGIDO: LOSAS EN CONCRETO HIDRÁULICO MR45 E=0.18M acelerado 7 días | 3d | 2026-11-06 | 2026-11-10 | 37, 38, 35SS+12d | 16d |  |
| 40 | 1.22.17 | VIGAS DE CIMENTACIÓN EN CONCRETO PREMEZCLADO DE 3000 PSI (21MPA) GRAVA COMÚN (incluye suministro, formaleteo metálico, colocación y curado. No incluye refuerzo) | 3d | 2026-11-06 | 2026-11-10 | 37, 38, 35SS+12d | 16d |  |
| 41 | 1.22.18 | CONSTRUCCIÓN DE ESCALERAS EN CONCRETO 3000 PSI GRAVA COMÚN. INCLUYE EXCAVACIÓN MANUAL, SUBBASE GRANULAR CLASE B, ACERO DE REFUERZO Y TRANSPORTE Y DISPOSICIÓN FINAL DE ESCOMBROS. | 9d | 2026-10-23 | 2026-11-04 | 35 | 15d | 0d |
